# Proyecto de Ejemplo 1

Schedule from MS Project, 2024-10-01 to 2026-04-30, 6 hours a day.

## Calendars

- Calendario L-Mi-V: Mon 08:00-12:00, 13:00-15:00; Tue off; Wed 08:00-12:00, 13:00-15:00; Thu off; Fri 08:00-12:00, 13:00-15:00; Sat-Sun off. Exceptions (off unless hours are given): 2025-01-01 (Año Nuevo), 2025-01-06 (Dia de Reyes), 2025-01-21 (Virgen De La Altagracia), 2025-02-27 (Independencia Nacional), 2025-04-17 (Jueves Santos), 2025-04-18 (Viernes santos), 2025-05-01 (Dia Del Trabajador), 2025-06-19 (Corpus Christi), 2025-09-24 (Dia de La Mercedes), 2025-11-10 (Dia de La Constitucion), 2025-12-24 (Noche Buena), 2025-12-25 (Navidad), 2025-12-31 (Fin de Año), 2026-01-01 (Año Nuevo), 2026-01-06 (Dia de Reyes), 2026-01-21 (Dia de La Altagracia), 2026-01-26 (Juan Pablo Duarte), 2026-02-27 (Independencia), 2026-04-02 (Jueves Santos), 2026-04-03 (Viernes Santos).
- Calendario Ma y J: Mon off; Tue 08:00-12:00, 13:00-15:00; Wed off; Thu 08:00-12:00, 13:00-15:00; Fri-Sun off. Exceptions (off unless hours are given): 2025-01-01 (Año Nuevo), 2025-01-06 (Dia de Reyes), 2025-01-21 (Virgen De La Altagracia), 2025-02-27 (Independencia Nacional), 2025-04-17 (Jueves Santos), 2025-04-18 (Viernes Santos), 2025-05-01 (Dia Del Trabajador), 2025-06-19 (Corpus Christi), 2025-08-16 (Dia de la Restauracion), 2025-09-24 (Dia de Las Mercedes), 2025-11-10 (Dia de la Constitucion), 2025-12-24 (Noche Buena), 2025-12-25 (Navidad), 2025-12-31 (Fin de Año), 2026-01-01 (Año Nuevo), 2026-01-06 (Dia de Reyes), 2026-01-21 (Dia de La Altagracia), 2026-01-26 (Dia de Duarte), 2026-02-27 (Independencia), 2026-04-02 (Jueves Santos), 2026-04-03 (Viernes Santos).
- Estándar con día feriados: Mon-Fri 09:00-13:00, 15:00-19:00; Sat-Sun off. Exceptions (off unless hours are given): 2025-01-01 (Año Nuevo), 2025-01-06 (Dia de Reyes), 2025-01-21 (Virgen de la Altagracia), 2025-02-27 (Independencia Nacional), 2025-04-17 (Jueves Santos), 2025-04-18 (Viernes Santos), 2025-05-01 (Dia del Trabajador), 2025-06-19 (Corpus Christi), 2025-09-24 (Dia de Las Mercedes), 2025-11-10 (Dia de la Constitucion), 2025-12-24 (Noche Buena), 2025-12-25 (Navidad), 2025-12-31 (Fin de Año), 2026-01-01 (Año Nuevo), 2026-01-06 (Dis de Reyes), 2026-01-21 (Virgen de La Altagracia), 2026-01-26 to 2026-01-27 (Dia de Juan Pablo Duarte), 2026-02-27 (Independencia Nacional), 2026-04-02 (Jueves Santos), 2026-04-03 (Viernes Santos).

## Resources

| Resource |
| --- |
| Hoyero 1 |
| Hoyero 2 |
| Hoyero 3 |
| Hoyero 4 |
| Hoyero 5 |
| Hoyero 6 |
| Hoyero 7 |
| Hoyero 8 |
| Hoyero 9 |
| Hoyero 10 |
| Grúa 1 |
| Grúa 2 |
| Grúa 3 |
| Grúa 4 |
| Grúa 5 |
| Grúa 6 |
| Grúa 7 |
| Grúa 8 |
| Grúa 9 |
| Grúa 10 |
| Canasto 1 |
| Canasto 2 |
| Canasto 3 |
| Canasto 4 |
| Canasto 5 |
| Canasto 6 |
| Canasto 7 |
| Canasto 8 |
| Canasto 9 |
| Canasto 10 |
| Brigada de Normalización 1 |
| Brigada de Normalización 2 |
| Brigada de Normalización 3 |
| Brigada de Normalización 4 |
| Brigada de Normalización 5 |
| Brigada de Normalización 6 |
| Brigada de Normalización 7 |
| Brigada de Normalización 8 |
| Brigada de Normalización 9 |
| Brigada de Normalización 10 |
| Supervisor 1 |
| Supervisor 2 |
| Supervisor 3 |
| Supervisor 4 |
| Supervisor 5 |
| Supervisor 6 |
| Supervisor 7 |
| Supervisor 8 |
| Supervisor 9 |
| Supervisor 10 |
| Capataz 1 |
| Capataz 2 |
| Capataz 3 |
| Capataz 4 |
| Capataz 5 |
| Capataz 6 |
| Capataz 7 |
| Capataz 8 |
| Capataz 9 |
| Capataz 10 |
| Brigada de Poda 1 |
| Brigada de Poda 2 |
| Brigada de Poda 3 |
| Brigada de Poda 4 |
| Brigada de Poda 5 |
| Brigada de Poda 6 |
| Brigada de Poda 7 |
| Brigada de Poda 8 |
| Brigada de Poda 9 |
| Brigada de Poda 10 |
| Brigada Ligera 1 |
| Brigada Ligera 2 |
| Brigada Ligera 3 |
| Brigada Ligera 4 |
| Brigada Ligera 5 |
| Brigada Ligera 6 |
| Brigada Ligera 7 |
| Brigada Ligera 8 |
| Brigada Ligera 9 |
| Brigada Ligera 10 |
| Hoyero 1 A |
| Hoyero 2 B |
| Hoyero 3 C |
| Hoyero 4 D |
| Hoyero 5 E |
| Hoyero 6 F |
| Hoyero 7 G |
| Hoyero 8 H |
| Hoyero 9 I |
| Hoyero 10 J |
| Grúa 1 A |
| Grúa 2 B |
| Grúa 3 C |
| Grúa 4 D |
| Grúa 5 E |
| Grúa 6 F |
| Grúa 7 G |
| Grúa 8 H |
| Grúa 9 I |
| Grúa 10 J |
| Canasto 1 A |
| Canasto 2 B |
| Canasto 3 C |
| Canasto 4 D |
| Canasto 5 E |
| Canasto 6 F |
| Canasto 7 G |
| Canasto 8 H |
| Canasto 9 I |
| Canasto 10 J |
| Brigada de Normalización 1 A |
| Brigada de Normalización 2 B |
| Brigada de Normalización 3 C |
| Brigada de Normalización 4 D |
| Brigada de Normalización 5 E |
| Brigada de Normalización 6 F |
| Brigada de Normalización 7 G |
| Brigada de Normalización 8 H |
| Brigada de Normalización 9 I |
| Brigada de Normalización 10 J |
| Supervisor 1 A |
| Supervisor 2 B |
| Supervisor 3 C |
| Supervisor 4 D |
| Supervisor 5 E |
| Supervisor 6 F |
| Supervisor 7 G |
| Supervisor 8 H |
| Supervisor 9 I |
| Supervisor 10 J |
| Capataz 1 A |
| Capataz 2 B |
| Capataz 3 C |
| Capataz 4 D |
| Capataz 5 E |
| Capataz 6 F |
| Capataz 7 G |
| Capataz 8 H |
| Capataz 9 I |
| Capataz 10 J |
| Brigada de Poda 1 A |
| Brigada de Poda 2 B |
| Brigada de Poda 3 C |
| Brigada de Poda 4 D |
| Brigada de Poda 5 E |
| Brigada de Poda 6 F |
| Brigada de Poda 7 G |
| Brigada de Poda 8 H |
| Brigada de Poda 9 I |
| Brigada de Poda 10 J |
| Brigada Ligera 1 A |
| Brigada Ligera 2 B |
| Brigada Ligera 3 C |
| Brigada Ligera 4 D |
| Brigada Ligera 5 E |
| Brigada Ligera 6 F |
| Brigada Ligera 7 G |
| Brigada Ligera 8 H |
| Brigada Ligera 9 I |
| Brigada Ligera 10 J |
| Hoyero 11 |
| Hoyero 12 |
| Hoyero 13 |
| Hoyero 14 |
| Hoyero 15 |
| Hoyero 11 K |
| Hoyero 12 L |
| Hoyero 13 M |
| Hoyero 14 N |
| Hoyero 15 Ñ |
| Canasto 11 |
| Canasto 11 O |
| 6 actividades nuevas |
| 1 chat con mensajes nuevos |
| Canasto 12 P |
| Canasto 12 |

## Schedule

| ID | WBS | Task | Duration | Start | Finish | Predecessors | Total slack | Free slack | Constraint | Calendar | Resources | Work | Días Calendario | Cantidad |
| --- | --- | --- | --- | --- | --- | --- | --- | --- | --- | --- | --- | --- | --- | --- |
| 1 | 1 | **Proyecto Lote 6 Cronograma CENO101/SAL101NE** | 522d | 2024-10-01 | 2026-04-30 |  | 0d |  |  | Estándar con día feriados |  | 20340h | 577días |  |
| 2 | 1.1 | **Preparativos previos Obras** | 44d | 2024-10-01 | 2024-11-14 |  | 5.33d |  |  | Estándar con día feriados |  |  | 45días |  |
| 3 | 1.1.1 | Reuniones con Contratista | 5d | 2024-10-01 | 2024-10-04 |  | 5.33d | 0d | start no earlier than 2024-10-01 | Estándar con día feriados |  |  | 4días |  |
| 4 | 1.1.2 | Revisiones adicionales de Ingenieria-Replanteo | 30d | 2024-10-07 | 2024-11-06 | 3FS+1d | 5.33d | 0d |  | Estándar con día feriados |  |  | 31días |  |
| 5 | 1.1.3 | Firma Minuta | 7d | 2024-11-07 | 2024-11-14 | 4FS+1d | 5.33d | 0d |  | Estándar con día feriados |  |  | 8días |  |
| 6 | 1.1.4 | Obtension Recursos Contratista | 30d | 2024-10-07 | 2024-11-06 |  | 486.67d |  | start no earlier than 2024-10-07 | Estándar con día feriados |  |  | 31días |  |
| 7 | 1.1.5 | Gestion de Materiales y Revision contra Fichas Tecnicas | 21d | 2024-10-07 | 2024-10-29 | 3FS+1d | 495d |  |  | Estándar con día feriados |  |  | 23días |  |
| 8 | 1.2 | **Suministro Materiales** | 119d | 2024-10-17 | 2025-02-24 |  | 387d |  |  | Estándar con día feriados |  |  | 131días |  |
| 9 | 1.2.1 | Suministro Postes | 90d | 2024-10-17 | 2025-01-23 | 4SS+10d | 387d | 0d |  | Estándar con día feriados |  |  | 99días |  |
| 10 | 1.2.2 | Suministro Armados | 90d | 2024-10-31 | 2025-02-06 | 9SS+14d | 387d | 0d |  | Estándar con día feriados |  |  | 99días |  |
| 11 | 1.2.3 | Suministro Tendido (Cables) | 90d | 2024-11-15 | 2025-02-24 | 10SS+15d | 387d | 0d |  | Estándar con día feriados |  |  | 102días |  |
| 12 | 1.2.4 | Suministro Transformadores | 90d | 2024-11-15 | 2025-02-24 | 11SS | 387d |  |  | Estándar con día feriados |  |  | 102días |  |
| 13 | 1.2.5 | Suministro Equipos Proteccion | 90d | 2024-11-15 | 2025-02-24 | 11SS | 387d |  |  | Estándar con día feriados |  |  | 102días |  |
| 14 | 1.2.6 | Suminiostro Alumbrado Publico | 90d | 2024-11-15 | 2025-02-24 | 11SS | 387d |  |  | Estándar con día feriados |  |  | 102días |  |
| 15 | 1.2.7 | Suministro Acometida y medidores | 90d | 2024-11-15 | 2025-02-24 | 11SS | 387d |  |  | Estándar con día feriados |  |  | 102días |  |
| 16 | 1.3 | **Ejecucion de Obras** | 216d | 2024-11-18 | 2026-04-30 |  | 0d |  |  |  |  | 20340h | 529días |  |
| 17 | 1.3.1 | **Poligono 1** | 81d | 2024-11-18 | 2025-05-30 |  | 30d |  |  |  |  | 2874h | 194días |  |
| 18 | 1.3.1.1 | Excavaciones | 7d | 2024-11-18 | 2024-12-02 | 5FS+1d | 30d | 0d |  |  | Hoyero 1; Hoyero 2; Hoyero 3; Hoyero 4; Hoyero 5; Hoyero 6; Hoyero 7; Hoyero 8; Hoyero 9; Hoyero 10; Hoyero 11; Hoyero 12; Hoyero 13; Hoyero 14; Hoyero 15 | 630h | 15días | 417 |
| 19 | 1.3.1.2 | Izado de postes | 9d | 2024-11-18 | 2024-12-06 | 18SS | 135d | 0d |  |  | Grúa 1; Grúa 2; Grúa 3; Grúa 4 | 216h | 19días | 241 |
| 20 | 1.3.1.3 | Cimentaciones | 3d | 2024-12-02 | 2024-12-06 | 19SS+6d | 207d |  |  |  | Brigada Ligera 1; Brigada Ligera 2 | 36h | 5días | 34 |
| 21 | 1.3.1.4 | Retenidas | 9d | 2024-11-20 | 2024-12-09 | 19SS+1d | 206d |  |  |  | Brigada Ligera 3; Brigada Ligera 4; Canasto 1 | 162h | 20días | 176 |
| 22 | 1.3.1.5 | Armados MT y BT | 12d | 2024-11-20 | 2024-12-16 | 19SS+1d | 135d | 0d |  |  | Canasto 5; Canasto 2; Canasto 3; Canasto 4; Canasto 6 | 360h | 27días | 464 |
| 23 | 1.3.1.6 | Tendido de Conductor MT y BT | 13d | 2024-12-18 | 2025-01-20 | 22 | 135d | 0d |  |  | Canasto 1; Canasto 2; Canasto 3; Canasto 4; Canasto 5 | 390h | 34días | 23,565 |
| 24 | 1.3.1.7 | Puesta a Tierra | 6d | 2025-01-22 | 2025-02-03 | 23 | 174d | 0d |  |  | Canasto 2; Canasto 3; Canasto 1 | 108h | 13días | 181 |
| 25 | 1.3.1.8 | Conexiones y Jumper | 5d | 2025-01-22 | 2025-01-31 | 23 | 135d | 0d |  |  | Canasto 4; Canasto 5; Canasto 6 | 90h | 10días | 161 |
| 26 | 1.3.1.9 | Transformadores | 2d | 2025-02-07 | 2025-02-10 | 24FS+1d | 174d | 0d |  |  | Canasto 2; Grúa 1; Grúa 2; Canasto 1; Grúa 3; Canasto 3 | 54h | 4días | 19 |
| 27 | 1.3.1.10 | Alumbrado Público | 7d | 2025-02-12 | 2025-02-26 | 26 | 174d |  |  |  | Canasto 1; Canasto 2; Canasto 3 | 126h | 15días | 324 |
| 28 | 1.3.1.11 | Etiquetas CT | 2d | 2025-02-03 | 2025-02-05 | 25 | 135d | 0d |  |  | Canasto 4; Canasto 5 | 24h | 3días | 46 |
| 29 | 1.3.1.12 | Totalizadores | 5d | 2025-02-07 | 2025-02-17 | 28 | 135d | 0d |  |  | Canasto 4; Canasto 5; Canasto 6 | 90h | 11días | 46 |
| 30 | 1.3.1.13 | Acometida | 37d | 2025-02-12 | 2025-05-09 | 29SS+2d | 135d | 0d |  |  | Brigada de Normalización 1; Brigada de Normalización 2 | 444h | 87días | 1,498 |
| 31 | 1.3.1.14 | Remoción | 6d | 2025-05-19 | 2025-05-30 | 30FS+3d | 135d |  |  |  | Canasto 1; Grúa 1; Grúa 2; Canasto 2 | 144h | 12días | 603 |

Notes:
- 19: No se le asigna canasto, pero requiere uno para apertura y cierre de seccionador
- 23: Con una grua es suficiente para darle apoyo a los canastos.

| ID | WBS | Task | Duration | Start | Finish | Predecessors | Total slack | Free slack | Calendar | Resources | Work | Días Calendario | Cantidad |
| --- | --- | --- | --- | --- | --- | --- | --- | --- | --- | --- | --- | --- | --- |
| 33 | 1.3.2 | **Poligono 2** | 110d | 2024-11-21 | 2025-08-12 |  | 2d |  |  |  | 1674h | 265días |  |
| 34 | 1.3.2.1 | Excavaciones | 4d | 2024-11-21 | 2024-12-03 | 5FS+1d | 1d | 0d | Calendario Ma y J | Hoyero 1 A; Hoyero 2 B; Hoyero 3 C; Hoyero 4 D; Hoyero 5 E; Hoyero 6 F; Hoyero 7 G; Hoyero 8 H; Hoyero 9 I; Hoyero 10 J; Hoyero 11 K; Hoyero 12 L; Hoyero 13 M; Hoyero 14 N; Hoyero 15 Ñ | 360h | 13días | 249 |
| 35 | 1.3.2.2 | Izado de postes | 4d | 2024-11-21 | 2024-12-03 | 34SS | 1d | 0d | Calendario Ma y J | Grúa 1 A; Grúa 2 B; Grúa 3 C; Grúa 4 D; Grúa 5 E | 120h | 13días | 137 |
| 36 | 1.3.2.3 | Cimentaciones | 1d | 2024-12-05 | 2024-12-05 | 35 | 1d | 0d | Calendario Ma y J | Brigada Ligera 1 A; Brigada Ligera 2 B; Brigada Ligera 3 C | 18h | 1días | 14 |
| 37 | 1.3.2.4 | Retenidas | 3d | 2024-12-10 | 2024-12-17 | 36 | 1d | 0d | Calendario Ma y J | Brigada Ligera 4 D; Canasto 1 A; Canasto 2 B; Brigada Ligera 1 A; Brigada Ligera 2 B; Brigada Ligera 3 C | 108h | 8días | 112 |
| 38 | 1.3.2.5 | Armados MT y BT | 7d | 2024-12-19 | 2025-01-09 | 37 | 1d | 0d | Calendario Ma y J | Canasto 5 E; Canasto 1 A; Canasto 2 B; Canasto 3 C; Canasto 4 D | 210h | 22días | 270 |
| 39 | 1.3.2.6 | Tendido de Conductor MT y BT | 8d | 2025-01-14 | 2025-02-11 | 38 | 1d | 0d | Calendario Ma y J | Canasto 1 A; Canasto 2 B; Canasto 3 C; Canasto 4 D; Canasto 5 E | 240h | 29días | 13,320 |
| 40 | 1.3.2.7 | Puesta a Tierra | 2d | 2025-02-13 | 2025-02-18 | 39 | 1d | 0d | Calendario Ma y J | Canasto 1 A; Canasto 2 B; Canasto 3 C; Canasto 4 D; Canasto 5 E | 60h | 6días | 103 |
| 41 | 1.3.2.8 | Conexiones y Jumper | 1d | 2025-02-20 | 2025-02-20 | 40 | 1d | 0d | Calendario Ma y J | Canasto 4 D; Canasto 5 E; Canasto 1 A; Canasto 2 B; Canasto 3 C | 30h | 1días | 66 |
| 42 | 1.3.2.9 | Transformadores | 1d | 2025-02-25 | 2025-02-25 | 41 | 1d | 0d | Calendario Ma y J | Grúa 1 A; Canasto 1 A | 12h | 1días |  |
| 43 | 1.3.2.10 | Alumbrado Público | 3d | 2025-03-11 | 2025-03-18 | 42 | 1d |  | Calendario Ma y J | Canasto 1 A; Canasto 3 C; Canasto 2 B; Canasto 4 D; Canasto 5 E | 72h | 8días | 174 |
| 44 | 1.3.2.11 | Etiquetas CT | 1d | 2025-04-08 | 2025-04-08 | 43 | 1d | 0d | Calendario Ma y J | Canasto 1 A; Canasto 2 B | 12h | 1días | 26 |
| 45 | 1.3.2.12 | Totalizadores | 2d | 2025-04-10 | 2025-04-15 | 44 | 1d | 0d | Calendario Ma y J | Canasto 5 E; Canasto 3 C; Canasto 4 D; Canasto 1 A; Canasto 2 B | 60h | 6días | 26 |
| 46 | 1.3.2.13 | Acometida | 24d | 2025-04-10 | 2025-07-10 | 44SS+1d | 71d | 0d | Calendario Ma y J | Brigada de Normalización 1 A; Brigada de Normalización 2 B | 288h | 92días | 940 |
| 47 | 1.3.2.14 | Remoción | 7d | 2025-07-22 | 2025-08-12 | 46FS+2d | 71d |  | Calendario Ma y J | Grúa 1 A; Canasto 5 E | 84h | 22días | 343 |
| 49 | 1.3.3 | **Poligono 3** | 145d | 2024-12-10 | 2025-11-25 |  | 61d |  |  |  | 3366h | 351días |  |
| 50 | 1.3.3.1 | Excavaciones | 9d | 2024-12-10 | 2025-01-07 | 34FS+1d | 41d | 0d | Calendario Ma y J | Hoyero 1 A; Hoyero 2 B; Hoyero 3 C; Hoyero 4 D; Hoyero 5 E; Hoyero 6 F; Hoyero 7 G; Hoyero 8 H; Hoyero 9 I; Hoyero 10 J; Hoyero 11 K; Hoyero 12 L; Hoyero 14 N; Hoyero 15 Ñ; Hoyero 13 M | 810h | 29días | 540 |
| 51 | 1.3.3.2 | Izado de postes | 9d | 2024-12-10 | 2025-01-07 | 50SS | 41d | 0d | Calendario Ma y J | Grúa 1 A; Grúa 2 B; Grúa 3 C; Grúa 4 D | 216h | 29días | 258 |
| 52 | 1.3.3.3 | Cimentaciones | 1d | 2025-01-07 | 2025-01-07 | 51FF | 128d |  | Calendario Ma y J | Brigada Ligera 1 A; Brigada Ligera 2 B | 12h | 1días | 12 |
| 53 | 1.3.3.4 | Retenidas | 6d | 2025-01-09 | 2025-01-30 | 51 | 41d | 0d | Calendario Ma y J | Brigada Ligera 3 C; Brigada Ligera 1 A; Brigada Ligera 2 B; Brigada Ligera 4 D; Brigada Ligera 5 E; Canasto 6 F; Canasto 7 G | 252h | 22días | 282 |
| 54 | 1.3.3.5 | Armados MT y BT | 14d | 2025-02-04 | 2025-03-25 | 53 | 41d | 0d | Calendario Ma y J | Canasto 7 G; Canasto 8 H; Canasto 9 I; Canasto 10 J; Canasto 6 F | 420h | 50días | 543 |
| 55 | 1.3.3.6 | Tendido de Conductor MT y BT | 21d | 2025-03-27 | 2025-06-12 | 54 | 41d | 0d | Calendario Ma y J | Canasto 6 F; Canasto 7 G; Canasto 8 H; Canasto 9 I; Canasto 10 J | 630h | 78días | 37,089 |
| 56 | 1.3.3.7 | Puesta a Tierra | 4d | 2025-06-17 | 2025-07-01 | 55 | 41d | 0d | Calendario Ma y J | Canasto 6 F; Canasto 7 G; Canasto 8 H; Canasto 9 I; Canasto 10 J | 120h | 15días | 210 |
| 57 | 1.3.3.8 | Conexiones y Jumper | 4d | 2025-07-03 | 2025-07-15 | 56 | 41d | 0d | Calendario Ma y J | Canasto 10 J; Canasto 6 F; Canasto 7 G; Canasto 8 H; Canasto 9 I | 120h | 13días | 193 |
| 58 | 1.3.3.9 | Transformadores | 1d | 2025-07-17 | 2025-07-17 | 57 | 41d | 0d | Calendario Ma y J | Canasto 6 F; Canasto 7 G; Canasto 8 H; Grúa 1 A; Grúa 2 B; Grúa 3 C; Canasto 9 I; Canasto 10 J; Grúa 4 D; Grúa 5 E | 60h | 1días | 16 |
| 59 | 1.3.3.10 | Alumbrado Público | 6d | 2025-07-22 | 2025-08-07 | 58 | 41d | 0d | Calendario Ma y J | Canasto 9 I; Canasto 10 J; Canasto 6 F; Canasto 7 G; Canasto 8 H | 180h | 17días | 417 |
| 60 | 1.3.3.11 | Etiquetas CT | 1d | 2025-08-12 | 2025-08-12 | 59 | 41d | 0d | Calendario Ma y J | Canasto 6 F; Canasto 7 G; Canasto 8 H | 18h | 1días | 53 |
| 61 | 1.3.3.12 | Totalizadores | 4d | 2025-08-14 | 2025-08-26 | 60 | 41d | 0d | Calendario Ma y J | Canasto 6 F; Canasto 7 G; Canasto 8 H; Canasto 9 I; Canasto 10 J | 120h | 13días | 53 |
| 62 | 1.3.3.13 | Acometida | 22d | 2025-09-04 | 2025-11-18 | 61FS+2d | 41d | 0d | Calendario Ma y J | Brigada de Normalización 3 C; Brigada de Normalización 4 D | 264h | 76días | 862 |
| 63 | 1.3.3.14 | Remoción | 6d | 2025-11-06 | 2025-11-25 | 62SS+18d | 41d |  | Calendario Ma y J | Canasto 9 I; Canasto 10 J; Grúa 3 C; Grúa 4 D | 144h | 20días | 646 |

Notes:
- 35: No se le asigna canasto, pero requiere uno para apertura y cierre de seccionador
- 39: Con una grua es suficiente para darle apoyo a los canastos.
- 51: No se le asigna canasto, pero requiere uno para apertura y cierre de seccionador
- 55: Con una grua es suficiente para darle apoyo a los canastos.

| ID | WBS | Task | Duration | Start | Finish | Predecessors | Total slack | Free slack | Resources | Work | Días Calendario | Cantidad |
| --- | --- | --- | --- | --- | --- | --- | --- | --- | --- | --- | --- | --- |
| 65 | 1.3.4 | **Poligono 4** | 177d | 2024-12-09 | 2026-02-13 |  | 30d |  |  | 6426h | 432días |  |
| 66 | 1.3.4.1 | Excavaciones | 19d | 2024-12-09 | 2025-01-24 | 18FS+2d | 30d | 0d | Hoyero 1; Hoyero 2; Hoyero 3; Hoyero 4; Hoyero 5; Hoyero 6; Hoyero 7; Hoyero 8; Hoyero 9; Hoyero 10; Hoyero 11; Hoyero 12; Hoyero 13; Hoyero 14; Hoyero 15 | 1710h | 47días | 1,118 |
| 67 | 1.3.4.2 | Izado de postes | 22d | 2024-12-09 | 2025-01-31 | 66SS | 30d | 0d | Grúa 1; Grúa 2; Grúa 3; Grúa 4 | 528h | 54días | 605 |
| 68 | 1.3.4.3 | Cimentaciones | 3d | 2025-01-27 | 2025-01-31 | 67FF | 30d | 0d | Brigada Ligera 1; Brigada Ligera 2; Brigada Ligera 3 | 54h | 5días | 46 |
| 69 | 1.3.4.4 | Retenidas | 10d | 2025-02-03 | 2025-03-05 | 68 | 30d | 0d | Brigada Ligera 1; Brigada Ligera 2; Brigada Ligera 3; Canasto 7; Canasto 8; Brigada Ligera 4; Brigada Ligera 5 | 420h | 31días | 513 |
| 70 | 1.3.4.5 | Armados MT y BT | 34d | 2025-03-07 | 2025-05-26 | 69 | 30d | 0d | Canasto 7; Canasto 8; Canasto 9; Canasto 10 | 816h | 81días | 1,076 |
| 71 | 1.3.4.6 | Tendido de Conductor MT y BT | 24d | 2025-05-28 | 2025-07-21 | 70 | 30d | 0d | Canasto 6; Canasto 7; Canasto 8; Canasto 9; Canasto 10 | 720h | 55días | 42,134 |
| 72 | 1.3.4.7 | Puesta a Tierra | 9d | 2025-07-23 | 2025-08-11 | 71 | 104d |  | Canasto 6; Canasto 7; Canasto 8 | 162h | 20días | 267 |
| 73 | 1.3.4.8 | Conexiones y Jumper | 14d | 2025-07-23 | 2025-08-22 | 71 | 30d | 0d | Canasto 9; Canasto 10 | 168h | 31días | 271 |
| 74 | 1.3.4.9 | Transformadores | 3d | 2025-08-25 | 2025-08-29 | 73 | 30d | 0d | Canasto 6; Canasto 7; Canasto 8; Canasto 9; Canasto 10; Grúa 1; Grúa 2; Grúa 3; Grúa 4; Grúa 5 | 180h | 5días | 52 |
| 75 | 1.3.4.10 | Alumbrado Público | 8d | 2025-09-01 | 2025-09-17 | 74 | 30d | 0d | Canasto 6; Canasto 7; Canasto 8; Canasto 9; Canasto 10 | 240h | 17días | 596 |
| 76 | 1.3.4.11 | Etiquetas CT | 2d | 2025-09-19 | 2025-09-22 | 75 | 86d |  | Canasto 6; Canasto 7 | 24h | 4días | 53 |
| 77 | 1.3.4.12 | Totalizadores | 6d | 2025-09-19 | 2025-10-03 | 75 | 30d | 0d | Canasto 8; Canasto 9; Canasto 10 | 108h | 15días | 53 |
| 78 | 1.3.4.13 | Acometida | 34d | 2025-09-22 | 2025-12-12 | 77SS+1d | 30d | 0d | Brigada de Normalización 1; Brigada de Normalización 2 | 408h | 82días | 1,350 |
| 79 | 1.3.4.14 | Remoción | 37d | 2025-11-12 | 2026-02-13 | 78SS+20d | 30d |  | Canasto 6; Canasto 7; Grúa 1; Grúa 2 | 888h | 94días | 1,513 |
| 81 | 1.3.5 | **Poligono 5** | 98d | 2025-01-29 | 2025-09-15 |  | 89d |  |  | 2700h | 230días |  |
| 82 | 1.3.5.1 | Excavaciones | 8d | 2025-01-29 | 2025-02-14 | 66FS+1d | 89d | 0d | Hoyero 5; Hoyero 6; Hoyero 7; Hoyero 8; Hoyero 9; Hoyero 10; Hoyero 11; Hoyero 12; Hoyero 13; Hoyero 14; Hoyero 15; Hoyero 1; Hoyero 2; Hoyero 3; Hoyero 4 | 720h | 17días | 502 |
| 83 | 1.3.5.2 | Izado de postes | 10d | 2025-02-12 | 2025-03-05 | 82SS | 89d | 0d | Grúa 2; Grúa 3; Grúa 4; Grúa 1 | 240h | 22días | 282 |
| 84 | 1.3.5.3 | Cimentaciones | 4d | 2025-03-07 | 2025-03-14 | 83 | 89d | 0d | Brigada Ligera 4; Brigada Ligera 5 | 48h | 8días | 44 |
| 85 | 1.3.5.4 | Retenidas | 11d | 2025-03-17 | 2025-04-09 | 84 | 89d | 0d | Brigada Ligera 5; Brigada Ligera 4; Canasto 5 | 132h | 24días | 220 |
| 86 | 1.3.5.5 | Armados MT y BT | 14d | 2025-04-11 | 2025-05-14 | 85 | 89d | 0d | Canasto 4; Canasto 5; Canasto 2; Canasto 1; Canasto 3 | 420h | 34días | 566 |
| 87 | 1.3.5.6 | Tendido de Conductor MT y BT | 22d | 2025-05-16 | 2025-07-04 | 86 | 89d | 0d | Canasto 4; Canasto 5; Canasto 3 | 396h | 50días | 22,830 |
| 88 | 1.3.5.7 | Puesta a Tierra | 3d | 2025-07-07 | 2025-07-11 | 87 | 89d | 0d | Canasto 4; Canasto 3; Canasto 1; Canasto 2; Canasto 5 | 90h | 5días | 141 |
| 89 | 1.3.5.8 | Conexiones y Jumper | 3d | 2025-07-14 | 2025-07-18 | 88 | 89d | 0d | Canasto 5; Canasto 1; Canasto 2; Canasto 3; Canasto 4 | 90h | 5días | 152 |
| 90 | 1.3.5.9 | Transformadores | 2d | 2025-07-23 | 2025-07-25 | 89FS+1d | 89d | 0d | Grúa 1; Grúa 2; Grúa 3; Canasto 1; Canasto 2; Canasto 3 | 72h | 3días | 17 |
| 91 | 1.3.5.10 | Alumbrado Público | 4d | 2025-07-28 | 2025-08-04 | 90 | 89d | 0d | Canasto 4; Canasto 2; Canasto 1; Canasto 3; Canasto 5 | 120h | 8días | 297 |
| 92 | 1.3.5.11 | Etiquetas CT | 1d | 2025-08-06 | 2025-08-06 | 91 | 89d | 0d | Canasto 1; Canasto 2 | 12h | 1días | 33 |
| 93 | 1.3.5.12 | Totalizadores | 3d | 2025-08-08 | 2025-08-13 | 92 | 89d | 0d | Canasto 1; Canasto 2; Canasto 3; Canasto 4 | 72h | 6días | 33 |
| 94 | 1.3.5.13 | Acometida | 10d | 2025-08-11 | 2025-09-01 | 93SS+1d | 89d | 0d | Brigada de Normalización 3; Brigada de Normalización 4 | 120h | 22días | 418 |
| 95 | 1.3.5.14 | Remoción | 7d | 2025-09-01 | 2025-09-15 | 94SS+9d | 89d |  | Canasto 1; Grúa 1; Grúa 2; Canasto 2 | 168h | 15días | 706 |

Notes:
- 67: No se le asigna canasto, pero requiere uno para apertura y cierre de seccionador
- 71: Con una grua es suficiente para darle apoyo a los canastos.
- 83: No se le asigna canasto, pero requiere uno para apertura y cierre de seccionador
- 87: Con una grua es suficiente para darle apoyo a los canastos.

| ID | WBS | Task | Duration | Start | Finish | Predecessors | Total slack | Free slack | Calendar | Resources | Work | Días Calendario | Cantidad |
| --- | --- | --- | --- | --- | --- | --- | --- | --- | --- | --- | --- | --- | --- |
| 97 | 1.3.6 | **Poligono 6** | 125d | 2025-01-23 | 2026-04-30 |  | 0d |  | Calendario Ma y J |  | 3300h | 463días |  |
| 98 | 1.3.6.1 | Excavaciones | 10d | 2025-01-23 | 2025-02-25 | 50FS+3d | 114d | 0d | Calendario Ma y J | Hoyero 1 A; Hoyero 2 B; Hoyero 3 C; Hoyero 4 D; Hoyero 5 E; Hoyero 6 F; Hoyero 7 G; Hoyero 8 H; Hoyero 9 I; Hoyero 10 J; Hoyero 11 K; Hoyero 12 L; Hoyero 13 M; Hoyero 14 N; Hoyero 15 Ñ | 900h | 34días | 589 |
| 99 | 1.3.6.2 | Izado de postes | 11d | 2025-01-23 | 2025-03-04 | 98SS | 114d | 0d | Calendario Ma y J | Grúa 2 B; Grúa 3 C; Grúa 4 D; Grúa 5 E | 264h | 41días | 308 |
| 100 | 1.3.6.3 | Cimentaciones | 7d | 2025-02-06 | 2025-03-04 | 99FF | 114d |  | Calendario Ma y J | Brigada Ligera 1 A; Brigada Ligera 2 B | 84h | 27días | 69 |
| 101 | 1.3.6.4 | Retenidas | 6d | 2025-04-22 | 2025-05-13 | 45 | 1d | 0d | Calendario Ma y J | Brigada Ligera 4 D; Brigada Ligera 5 E; Brigada Ligera 1 A; Brigada Ligera 2 B; Brigada Ligera 3 C | 180h | 22días | 281 |
| 102 | 1.3.6.5 | Armados MT y BT | 16d | 2025-05-15 | 2025-07-10 | 101 | 1d | 0d | Calendario Ma y J | Canasto 1 A; Canasto 2 B; Canasto 3 C; Canasto 5 E; Canasto 4 D | 480h | 57días | 628 |
| 103 | 1.3.6.6 | Tendido de Conductor MT y BT | 16d | 2025-07-15 | 2025-09-04 | 102 | 1d |  | Calendario Ma y J | Canasto 1 A; Canasto 2 B; Canasto 3 C; Canasto 4 D | 384h | 52días | 21,756 |
| 104 | 1.3.6.7 | Puesta a Tierra | 4d | 2025-09-30 | 2025-10-09 | 103 | 0d |  | Calendario Ma y J | Canasto 1 A; Canasto 2 B; Canasto 3 C; Canasto 4 D; Canasto 5 E | 120h | 10días | 188 |
| 105 | 1.3.6.8 | Conexiones y Jumper | 4d | 2025-10-14 | 2025-10-23 | 104 | 0d |  | Calendario Ma y J | Canasto 5 E; Canasto 4 D; Canasto 1 A; Canasto 2 B; Canasto 3 C | 120h | 10días | 178 |
| 106 | 1.3.6.9 | Transformadores | 1d | 2025-10-28 | 2025-10-28 | 105 | 0d |  | Calendario Ma y J | Canasto 1 A; Canasto 2 B; Canasto 3 C; Grúa 1 A; Grúa 2 B; Grúa 3 C; Canasto 4 D; Canasto 5 E; Grúa 4 D; Grúa 5 E | 60h | 1días | 17 |
| 107 | 1.3.6.10 | Alumbrado Público | 6d | 2025-10-30 | 2025-11-18 | 106 | 0d |  | Calendario Ma y J | Canasto 1 A; Canasto 2 B; Canasto 3 C; Canasto 5 E; Canasto 4 D | 180h | 20días | 414 |
| 108 | 1.3.6.11 | Etiquetas CT | 1d | 2025-12-18 | 2025-12-18 | 107 | 0d |  | Calendario Ma y J | Canasto 1 A; Canasto 2 B; Canasto 3 C | 18h | 1días | 47 |
| 109 | 1.3.6.12 | Totalizadores | 3d | 2025-12-23 | 2026-01-08 | 108 | 0d |  | Calendario Ma y J | Canasto 3 C; Canasto 5 E; Canasto 4 D; Canasto 1 A; Canasto 2 B | 90h | 17días | 47 |
| 110 | 1.3.6.13 | Acometida | 19d | 2026-01-15 | 2026-03-19 | 109FS+1d | 0d |  | Calendario Ma y J | Brigada de Normalización 1 A; Brigada de Normalización 2 B | 228h | 64días | 777 |
| 111 | 1.3.6.14 | Remoción | 8d | 2026-04-07 | 2026-04-30 | 110FS+3d | 0d |  | Calendario Ma y J | Grúa 1 A; Grúa 2 B; Canasto 1 A; Canasto 2 B | 192h | 24días | 770 |

Notes:
- 99: No se le asigna canasto, pero requiere uno para apertura y cierre de seccionador
- 103: Con una grua es suficiente para darle apoyo a los canastos.
